# High Level Plan for SAPBiz 10-22-08 v4

Schedule from MS Project, 2008-10-13 to 2010-01-28, A marks actual dates.
MIT

## Calendars

- Standard: Mon-Fri 08:00-12:00, 13:00-17:00; Sat-Sun off. Exceptions (off unless hours are given): 2008-10-18 to 2008-10-19, 2008-10-25 to 2008-10-26, 2008-11-01 to 2008-11-02, 2008-11-08 to 2008-11-09, 2008-11-11, 2008-11-15 to 2008-11-16, 2008-11-22 to 2008-11-23, 2008-11-27 to 2008-11-30, 2008-12-06 to 2008-12-07, 2008-12-13 to 2008-12-14 08:00-12:00, 13:00-17:00, 2008-12-20 to 2008-12-21, 2008-12-25 to 2008-12-28, 2009-01-01 to 2009-01-03.

## Resources

| Resource |
| --- |
| ABAP |
| BO |
| CAO |
| BASIS |
| BA |
| DEV |
| DWH |
| HR-P |
| ALL |
| 20 |
| BUS |
| 8 |
| 7 |
| REP |
| R3 |
| QA |
| FIN |
| LOG |
| EHS |
| HRP |
| IDD |
| ISS |
| R# |
| FQ |
| FI |
| PM |
| B |
| Elena |
| Wai-Ming |

## Schedule

| ID | WBS | Task | Type | Duration | Start | Finish | Predecessors | Complete | Remaining | Total slack | Free slack | Constraint | Work |
| --- | --- | --- | --- | --- | --- | --- | --- | --- | --- | --- | --- | --- | --- |
| 1 | 1 | **2009 Support Pack Implementation Project** |  | 334d? | 2008-10-13 A | 2010-01-28 |  | 12% | 292.86d? | 0d |  |  | 16h |
| 2 | 1.1 | **Project Prep & Planning** |  | 242d? | 2008-10-13 A | 2009-09-22 |  | 14% | 207.64d? | 92d |  |  |  |
| 3 | 1.1.1 | **Appoint project team, define roles and responsibilities** |  | 1d? | 2009-08-10 A | 2009-08-10 A |  | 100% |  |  |  |  |  |
| 4 | 1.1.1.1 | Appoint project manager |  | 1d? | 2009-08-10 A | 2009-08-10 A |  | 100% |  |  |  |  |  |
| 5 | 1.1.1.2 | Appoint core team |  | 1d? | 2009-08-10 A | 2009-08-10 A |  | 100% |  |  |  |  |  |
| 6 | 1.1.1.3 | Update business owner list with new / changed owners |  | 0.5d | 2009-08-10 A | 2009-08-10 A |  | 100% |  |  |  |  |  |
| 7 | 1.1.2 | **Define high level plan, milestones, deliverables** |  | 0.5d | 2009-08-10 A | 2009-08-10 A |  | 100% |  |  |  |  |  |
| 8 | 1.1.2.1 | Determine support packages availability date |  | 0.5d | 2009-08-10 A | 2009-08-10 A |  | 100% |  |  |  |  |  |
| 9 | 1.1.2.2 | Determine desired support package & enhancement package levels |  | 0.5d | 2009-08-10 A | 2009-08-10 A |  | 100% |  |  |  |  |  |
| 10 | 1.1.2.3 | Determine dates for production freeze |  | 0.5d | 2009-08-10 A | 2009-08-10 A |  | 100% |  |  |  |  |  |
| 11 | 1.1.3 | **Define environments, refresh schedule, support pack plan** |  | 28.5d? | 2009-07-01 A | 2009-08-10 |  | 60% | 11.4d? | 123.5d |  |  |  |
| 12 | 1.1.3.1 | Identify clients fo Staging, and TST (DEV not refreshed) |  | 0.5d | 2009-08-10 A | 2009-08-10 A |  | 100% |  |  |  |  |  |
| 13 | 1.1.3.2 | Determine production snapshot dates for STG, TST |  | 0.5d | 2009-08-10 A | 2009-08-10 A |  | 100% |  |  |  |  |  |
| 14 | 1.1.3.3 | Determine dates for STG, TST refreshes |  | 0.5d | 2009-08-10 A | 2009-08-10 A |  | 100% |  |  |  |  |  |
| 15 | 1.1.3.4 | Plan datawarehouse extracts |  | 1d? | 2009-07-01 | 2009-07-01 |  |  |  | 0d |  |  |  |
| 16 | 1.1.4 | **Cleanup pending transports** |  | 60d | 2009-07-01 A | 2009-09-22 |  | 26% | 44.32d | 92d |  |  |  |
| 17 | 1.1.4.1 | Create transport list |  | 1d | 2009-07-01 A | 2009-07-01 A |  | 100% |  |  |  |  |  |
| 18 | 1.1.4.2 | Determine status and plan for each |  | 5d | 2009-07-01 A | 2009-07-07 | 17 | 25% | 3.75d | 0d |  |  |  |
| 19 | 1.1.4.3 | Execute pending transport plan |  | 60d | 2009-07-01 A | 2009-09-22 |  | 25% | 45d | 0d |  |  |  |
| 20 | 1.1.5 | Upgrade Epi-use |  | 30d | 2009-07-01 | 2009-08-11 |  |  |  | 0d |  |  |  |
| 21 | 1.1.6 | **Test Planning** |  | 213.5d? | 2008-10-13 | 2009-08-13 |  |  |  | -16.25d | 0d |  |  |
| 22 | 1.1.6.1 | **Update test script catalogs** |  | 16d? | 2009-07-01 | 2009-07-22 |  |  |  | -198.25d | 0d |  |  |
| 23 | 1.1.6.1.1 | Define, document, communicate test case management procedure - templates, process, … |  | 1d? | 2009-07-01 | 2009-07-01 |  |  |  | 0d |  |  |  |
| 24 | 1.1.6.1.2 | Review transaction / report log for new items |  | 5d | 2009-07-01 | 2009-07-07 |  |  |  | -198.25d | 0d |  |  |
| 25 | 1.1.6.1.3 | Update test script catalog with new transactions / reports |  | 1d | 2009-07-08 | 2009-07-08 | 24 |  |  | -198.25d | 0d |  |  |
| 26 | 1.1.6.1.4 | Review test script catalog for missing / old test scripts |  | 2d | 2009-07-09 | 2009-07-10 | 25 |  |  | -198.25d | 0d |  |  |
| 27 | 1.1.6.1.5 | Create new / update old test scripts |  | 5d | 2009-07-13 | 2009-07-17 | 26 |  |  | -198.25d | 0d |  |  |
| 28 | 1.1.6.1.6 | Convert to new catalog |  | 1d? | 2009-07-20 | 2009-07-20 | 27 |  |  | -198.25d | 0d |  |  |
| 29 | 1.1.6.1.7 | Decide what to test in each functional area |  | 1d? | 2009-07-21 | 2009-07-21 | 28 |  |  | -198.25d | 0d |  |  |
| 30 | 1.1.6.1.8 | Convert test cases to new template |  | 1d? | 2009-07-22 | 2009-07-22 | 29 |  |  | -198.25d | 0d |  |  |
| 31 | 1.1.6.1.9 | Financial Team confirms completeness of test script catalog | milestone | 0d | 2009-07-22 | 2009-07-22 | 30 |  |  | -198.25d | 0d |  |  |
| 32 | 1.1.6.1.10 | Logistics Team confirms completeness of test script catalog | milestone | 0d | 2009-07-17 | 2009-07-17 | 27 |  |  | 139d |  | start no earlier than 2008-09-20 |  |
| 33 | 1.1.6.1.11 | EHS Team confirms completeness of test script catalog | milestone | 0d | 2009-07-17 | 2009-07-17 | 27 |  |  | 139d |  | start no earlier than 2008-09-20 |  |
| 34 | 1.1.6.1.12 | HR-Payroll Team confirms completeness of test script catalog | milestone | 0d | 2009-07-17 | 2009-07-17 | 27 |  |  | 120.5d | 0d | start no earlier than 2008-09-20 |  |

Notes:
- 1: 2008 plan 2382 hours. Actual / 2009 resource spreadsheet plan 3500 hours, $250K
- 8: 10/15/2009
- 20: Can be done any time before support packs. Ideally 1 month before support pack applied to dev. Provides scrambling in place capability. Won't change refresh requirements and process, but facilitates scrambling process (and time required).

| ID | WBS | Task | Type | Duration | Start | Finish | Predecessors | Complete | Remaining | Total slack | Free slack | Constraint |
| --- | --- | --- | --- | --- | --- | --- | --- | --- | --- | --- | --- | --- |
| 35 | 1.1.6.2 | **Unit Test Planning** |  | 1.5d | 2009-07-20 | 2009-07-21 |  |  |  | 120.5d |  |  |
| 36 | 1.1.6.2.1 | Determine transactions / reports to be tested |  | 1d | 2009-07-20 | 2009-07-20 | 34 |  |  | 120.5d | 0d |  |
| 37 | 1.1.6.2.2 | Update test script catalog |  | 0.5d | 2009-07-21 | 2009-07-21 | 36 |  |  | 120.5d | 0d |  |
| 38 | 1.1.6.3 | **Systems Integration Test Planning** |  | 17d | 2009-07-21 | 2009-08-13 |  |  |  | 120.5d |  |  |
| 39 | 1.1.6.3.1 | Define business scenarios |  | 2d | 2009-07-21 | 2009-07-23 | 37 |  |  | 120.5d | 0d |  |
| 40 | 1.1.6.3.2 | Document business scenarios |  | 10d | 2009-07-23 | 2009-08-06 | 39 |  |  | 120.5d | 0d |  |
| 41 | 1.1.6.3.3 | QA review of business scenarios |  | 3d | 2009-08-06 | 2009-08-11 | 40 |  |  | 120.5d | 0d |  |
| 42 | 1.1.6.3.4 | Update business scenarios as required |  | 1d | 2009-08-11 | 2009-08-12 | 41 |  |  | 120.5d | 0d |  |
| 43 | 1.1.6.3.5 | Financial Team confirms completeness of business scenarios | milestone | 0d | 2009-08-12 | 2009-08-12 | 42 |  |  | 121.5d |  |  |
| 44 | 1.1.6.3.6 | Logistics Team confirms completeness of business scenarios | milestone | 0d | 2009-08-12 | 2009-08-12 | 42 |  |  | 121.5d |  | start no earlier than 2008-09-20 |
| 45 | 1.1.6.3.7 | EHS Team confirms completeness of business scenarios | milestone | 0d | 2009-08-12 | 2009-08-12 | 42 |  |  | 121.5d |  | start no earlier than 2008-09-20 |
| 46 | 1.1.6.3.8 | HR-Payroll Team confirms completeness of business scenarios | milestone | 0d | 2009-08-12 | 2009-08-12 | 42 |  |  | 120.5d | 0d | start no earlier than 2008-09-20 |
| 47 | 1.1.6.3.9 | QA confirms completeness of business scenarios |  | 1d | 2009-08-12 | 2009-08-13 | 46 |  |  | 120.5d |  |  |
| 48 | 1.1.6.4 | **User Acceptance Test Planning** |  | 210.75d | 2008-10-13 | 2009-08-10 |  |  |  | -0.25d | 0d |  |
| 49 | 1.1.6.4.1 | Send test script catalog to business owners |  | 0.25d | 2009-08-10 | 2009-08-10 | 31, 6 |  |  | -1.25d | 0d | start no earlier than 2008-10-14 |
| 50 | 1.1.6.4.2 | Business owners select transactions and send back catalogs |  | 10d | 2008-10-13 | 2008-10-24 | 49 |  |  | -210.75d | 0d | finish no later than 2008-10-24 |
| 51 | 1.1.6.4.3 | Business owners define testers and send back list to Team leads |  | 10d | 2008-10-13 | 2008-10-24 | 49 |  |  | -210.75d | 0d | finish no later than 2008-10-24 |
| 52 | 1.1.6.4.4 | Business analysts update test script catalogs |  | 2d | 2008-10-27 | 2008-10-28 | 51 |  |  | 38d |  |  |
| 53 | 1.2 | **System Admin Preparation** |  | 78d? | 2009-07-01 A | 2009-10-16 |  | 79% | 16.42d? | 0d |  |  |
| 54 | 1.2.1 | Produce Support Package Notes |  | 1d | 2009-07-01 | 2009-07-01 |  |  |  | 151d |  |  |
| 55 | 1.2.2 | Review and update action log from previous year |  | 2d | 2009-07-01 | 2009-07-02 |  |  |  | 150d |  |  |
| 56 | 1.2.3 | Upgrade Epi-use |  | 1d? | 2009-07-01 | 2009-07-01 |  |  |  | 0d |  |  |
| 57 | 1.2.4 | PS Snapshot for SF3 |  | 1d? | 2009-09-28 A | 2009-09-28 A |  | 100% |  |  |  | start no earlier than 2009-09-28 |
| 58 | 1.2.5 | **SH3 Practice update (TBD)** |  | 7d | 2009-10-08 A | 2009-10-16 A |  | 100% |  |  |  |  |
| 59 | 1.2.5.1 | Test Install Basis Enhancement Pack 1 |  | 7d | 2009-10-08 A | 2009-10-16 A |  | 100% |  |  |  | finish no earlier than 2009-10-16 |
| 60 | 1.2.5.2 | Test Install Enhancement Pack 4 |  | 7d | 2009-10-08 A | 2009-10-16 A |  | 100% |  |  |  | finish no earlier than 2009-10-16 |
| 61 | 1.3 | Support packs available from SAP | milestone | 0d | 2009-10-15 A | 2009-10-15 A |  | 100% |  |  |  | start no earlier than 2009-10-15 |

Notes:
- 59: Test process / Resolve issues / Document process / Determine timings
- 60: Test process / Resolve issues / Document process / Determine timings

| ID | WBS | Task | Duration | Start | Finish | Predecessors | Complete | Remaining | Total slack | Free slack | Constraint | Resources | Work |
| --- | --- | --- | --- | --- | --- | --- | --- | --- | --- | --- | --- | --- | --- |
| 62 | 1.4 | **SF3 System Refresh** | 72d | 2009-07-01 A | 2009-10-08 |  | 56% | 32d | 76d | 9d |  |  |  |
| 63 | 1.4.1 | Refresh with 9/28/2009 PS1 Snapshot | 2d | 2009-07-01 A | 2009-07-02 A |  | 100% |  |  |  |  |  |  |
| 64 | 1.4.2 | Execute R3 Action Log | 0.5d | 2009-07-01 A | 2009-07-01 A |  | 100% |  |  |  |  |  |  |
| 65 | 1.4.3 | Scramble sensitive data | 2d | 2009-10-07 | 2009-10-08 |  |  |  | 44d |  | finish no earlier than 2009-10-08 |  |  |
| 66 | 1.5 | PS1 Snapshot for SH2 | 1d? | 2009-10-19 A | 2009-10-19 A |  | 100% |  |  |  | start no earlier than 2009-10-19 |  |  |
| 67 | 1.6 | DW pull & store extracts | 1d | 2009-10-20 | 2009-10-20 | 66 |  |  | 0d |  |  | Elena | 8h |
| 68 | 1.7 | **SFK Update (Evaluation)** | 6d? | 2009-10-19 A | 2009-10-26 | 61 | 13% | 5.2d? | 68d |  |  |  |  |
| 69 | 1.7.1 | Apply SAP kernel update | 0.5d | 2009-10-19 A | 2009-10-19 A |  | 100% |  |  |  | start no earlier than 2009-10-19 |  |  |
| 70 | 1.7.2 | Upgrade Oracle db | 0.5d | 2009-10-19 A | 2009-10-19 A | 69 | 100% |  |  |  | start no earlier than 2009-10-19 |  |  |
| 71 | 1.7.3 | Install Support packages, Basis Enhancement Pack 1, ERP EH 4, + Additional packages req'd for HR | 4d? | 2009-10-20 | 2009-10-23 | 70 |  |  | 0d |  | finish no earlier than 2009-10-23 |  |  |
| 72 | 1.7.4 | Validate security infrastructure (SNC) | 1d | 2009-10-26 | 2009-10-26 | 71 |  |  | 68d |  | finish no earlier than 2009-10-24 |  |  |
| 73 | 1.7.5 | Validate SAPGui interactions | 0.5d | 2009-10-26 | 2009-10-26 | 71 |  |  | 68.5d |  | finish no earlier than 2009-10-23 |  |  |
| 74 | 1.7.6 | Validate basic SAP functions work | 1d | 2009-10-26 | 2009-10-26 | 71 |  |  | 68d |  | finish no earlier than 2009-10-23 |  |  |
| 75 | 1.8 | **Zuttreq updates** | 83d? | 2009-07-01 | 2009-10-23 |  |  |  | 69d |  |  |  | 2h |
| 76 | 1.8.1 | Change target system for transport layer | 1d? | 2009-10-23 | 2009-10-23 |  |  |  | 0d |  | start no earlier than 2009-10-23 |  |  |
| 77 | 1.8.2 | Change target system in Zuttreq | 0.25d | 2009-07-01 | 2009-07-01 |  |  |  | 151.75d |  |  | Wai-Ming | 2h |
| 78 | 1.9 | **SF3 Update** | 9d? | 2009-10-22 | 2009-11-03 | 62 |  |  | 62d |  |  |  |  |
| 79 | 1.9.1 | Apply SAP kernel update | 0.5d | 2009-10-22 | 2009-10-22 |  |  |  | 68d | 0.5d | start no earlier than 2009-10-22 |  |  |
| 80 | 1.9.2 | Upgrade Oracle db | 0.5d | 2009-10-23 | 2009-10-23 | 79 |  |  | 67.5d | 0.5d | start no earlier than 2009-10-23 |  |  |
| 81 | 1.9.3 | Install Support packages, Basis Enhancement Pack 1, ERP EH 4, + Additional packages req'd for HR | 3d? | 2009-10-26 | 2009-10-28 | 80 |  |  | 66d |  | finish no earlier than 2009-10-28 |  |  |
| 82 | 1.9.4 | Update BSI | 3d? | 2009-10-26 | 2009-10-28 |  |  |  | 66d |  | finish no earlier than 2009-10-28 |  |  |
| 83 | 1.9.5 | SPAU, OSS notes | 2d? | 2009-10-29 | 2009-10-30 |  |  |  | 63d | 0d | finish no earlier than 2009-10-30 |  |  |
| 84 | 1.9.6 | Check, decide, apply MIT mods or use enhancement framework | 2d? | 2009-10-30 | 2009-11-02 |  |  |  | 63d |  | finish no earlier than 2009-11-02 |  |  |
| 85 | 1.9.7 | SAP developer functionality validation | 1d? | 2009-10-29 | 2009-10-29 |  |  |  | 0d |  | start no earlier than 2009-10-29 |  |  |
| 86 | 1.9.8 | Apply updates for SAML authentication | 1d? | 2009-11-02 | 2009-11-02 | 83 |  |  | 0d |  | start no earlier than 2009-10-30 |  |  |
| 87 | 1.9.9 | Apply updates for SAP connect email functionality | 1d? | 2009-11-03 | 2009-11-03 | 83 |  |  | 0d |  | start no earlier than 2009-11-03 |  |  |
| 88 | 1.9.10 | Validate - external interfaces ITS, jco, mitid, fax. | 1d? | 2009-11-03 | 2009-11-03 |  |  |  | 0d |  | start no earlier than 2009-11-03 |  |  |
| 89 | 1.10 | Open enrollment transports to production | 1d? | 2009-10-29 | 2009-10-29 |  |  |  | 0d |  | start no earlier than 2009-10-29 |  |  |
| 90 | 1.11 | Netweaver/Adobe Document Server Update (Larch) | 2d? | 2009-10-29 | 2009-10-30 |  |  |  | 64d |  | finish no earlier than 2009-10-30 |  |  |

Notes:
- 62: The SAP Staging system (SF3) is used for the introduction of SAP notes, SAP problem resolution, and the evaluation of SAP system updates.
- 66: Completed at midnight
- 67: Save 10/19 snapshot extracts. Performed by data warehouse.
- 68: Could this start 10/15 as soon as SP available from SAP? / After SH3 trial run. This can start.
- 70: Desireable Oracle 10.2.0.5. Not a showstopper. 10.2.0.4 with updates = back up plan. / 10.2.0.5 not out as of 10/13.
- 71: Estimate 2-7 days. / Use 3 days. / COnfirm with SH3 results.
- 80: Desireable Oracle 10.2.0.5. Not a showstopper. 10.2.0.4 with updates = back up plan. / 10.2.0.5 not out as of 10/13.
- 81: Estimate 2-7 days. / Use 3 days. / COnfirm with SH3 results.
- 82: Can be done anytime after 10/15. / While SF3 support packages task being performed.
- 87: SAP Connect functionality to be used by RFP project (need to verify).

| ID | WBS | Task | Type | Duration | Start | Finish | Predecessors | Total slack | Free slack | Constraint | Resources | Work |
| --- | --- | --- | --- | --- | --- | --- | --- | --- | --- | --- | --- | --- |
| 91 | 1.12 | **SF2 Update (Development)** |  | 2d? | 2009-10-30 | 2009-11-02 |  | 58.5d | 0d |  |  |  |
| 92 | 1.12.1 | Apply SAP kernel update |  | 1d | 2009-10-30 | 2009-10-30 |  | 59.5d |  | finish no earlier than 2009-10-30 |  |  |
| 93 | 1.12.2 | Upgrade Oracle db |  | 1d | 2009-10-30 | 2009-10-30 |  | 59.5d |  | finish no earlier than 2009-10-30 |  |  |
| 94 | 1.12.3 | Install Support packages, Basis Enhancement Pack 1, ERP EH 4, + Additional packages req'd for HR |  | 1d? | 2009-10-30 | 2009-11-01 |  | 59.5d |  | finish no earlier than 2009-11-01 |  |  |
| 95 | 1.12.4 | Apply updates for SAML authentication |  | 1d? | 2009-11-02 | 2009-11-02 |  | 58.5d |  | start no earlier than 2009-11-02 |  |  |
| 96 | 1.12.5 | Apply updates for SAP connect email functionality |  | 1d? | 2009-11-02 | 2009-11-02 |  | 58.5d |  | finish no earlier than 2009-11-02 |  |  |
| 97 | 1.12.6 | Import transports from SF3 |  | 0.5d | 2009-11-02 | 2009-11-02 |  | 59d |  | start no earlier than 2009-11-02 |  |  |
| 98 | 1.12.7 | Apply BSI Tax Factory Update |  | 0.25d | 2009-11-02 | 2009-11-02 |  | 59.25d |  | start no earlier than 2009-10-31 |  |  |
| 99 | 1.12.8 | Execute action log (add updates if necessary) |  | 0.5d | 2009-11-02 | 2009-11-02 |  | 59d |  | start no earlier than 2009-11-02 |  |  |
| 100 | 1.13 | **Unit Test Execution in SF2** |  | 4.5d | 2009-11-03 | 2009-11-09 | 91 | 58.5d |  |  |  |  |
| 101 | 1.13.1 | Financial Unit Tests, Issue identification and retest |  | 4.5d | 2009-11-03 | 2009-11-09 |  | 58.5d |  | start no earlier than 2009-11-03 |  |  |
| 102 | 1.13.2 | Logistics Unit Tests, Issue identification and retest |  | 4.5d | 2009-11-03 | 2009-11-09 |  | 58.5d |  | start no earlier than 2009-11-03 |  |  |
| 103 | 1.13.3 | EHS Unit Tests, Issue identification and retest |  | 4.5d | 2009-11-03 | 2009-11-09 |  | 58.5d |  | start no earlier than 2009-11-03 |  |  |
| 104 | 1.13.4 | HR-Payroll Unit Tests, Issue identification and retest |  | 4.5d | 2009-11-03 | 2009-11-09 |  | 58.5d |  | start no earlier than 2009-11-03 |  |  |
| 105 | 1.13.5 | All functional teams ok environment and move to SIT | milestone | 0d | 2009-11-08 | 2009-11-08 |  | 59d |  | start no earlier than 2009-11-08 |  |  |
| 106 | 1.14 | SH2 System Refresh |  | 5d? | 2009-10-26 | 2009-10-30 |  | 64d |  | finish no earlier than 2009-10-30 |  |  |
| 107 | 1.15 | **SH2 Update** |  | 3d? | 2009-11-04 | 2009-11-06 |  | 59d |  |  |  |  |
| 108 | 1.15.1 | Apply SAP kernel update |  | 1d | 2009-11-04 | 2009-11-04 |  | 61d |  | finish no earlier than 2009-11-04 |  |  |
| 109 | 1.15.2 | Upgrade Oracle db |  | 1d | 2009-11-04 | 2009-11-04 |  | 61d |  | finish no earlier than 2009-11-04 |  |  |
| 110 | 1.15.3 | Install Support packages, Basis Enhancement Pack 1, ERP EH 4, + Additional packages req'd for HR |  | 2d? | 2009-11-05 | 2009-11-06 |  | 59d |  | finish no earlier than 2009-11-06 |  |  |
| 111 | 1.15.4 | Apply BSI Tax Factory Update |  | 0.25d | 2009-11-05 | 2009-11-05 |  | 60.75d |  | start no earlier than 2009-11-05 |  |  |
| 112 | 1.15.5 | Apply updates for SAML authentication |  | 1d? | 2009-11-06 | 2009-11-06 |  | 59d |  | start no earlier than 2009-11-06 |  |  |
| 113 | 1.15.6 | Apply updates for SAP connect email functionality |  | 1d? | 2009-11-06 | 2009-11-06 |  | 59d |  | start no earlier than 2009-11-06 |  |  |
| 114 | 1.15.7 | Import transports from SF3 & SF2 |  | 0.5d | 2009-11-06 | 2009-11-06 |  | 59.5d |  | start no earlier than 2009-11-06 |  |  |
| 115 | 1.15.8 | Execute action log (add updates if necessary) |  | 0.5d | 2009-11-06 | 2009-11-06 |  | 59.5d |  | start no earlier than 2009-11-06 |  |  |
| 116 | 1.16 | Compare data warehouse extracts |  | 0.5d | 2009-07-01 | 2009-07-01 |  | 145.5d | 0d |  | Elena | 4h |

Notes:
- 91: 3 days - confirm this can be achieved during SFK updates
- 96: SAP Connect functionality to be used by RFP project (need to verify).
- 106: Depends on 10/19 snapshot
- 113: SAP Connect functionality to be used by RFP project (need to verify).

| ID | WBS | Task | Type | Duration | Start | Finish | Predecessors | Total slack | Free slack | Constraint |
| --- | --- | --- | --- | --- | --- | --- | --- | --- | --- | --- |
| 117 | 1.17 | **Execute System Integration Tests in SH2** |  | 103.5d | 2009-07-01 | 2009-11-23 |  | 48d |  |  |
| 118 | 1.17.1 | Execute System Integration Tests |  | 6d | 2009-07-01 | 2009-07-09 | 149, 116 | 145.5d |  |  |
| 119 | 1.17.2 | Financial Close |  | 1d | 2009-07-01 | 2009-07-02 | 149, 116 | 150.5d |  |  |
| 120 | 1.17.3 | Issue Retesting |  | 3d | 2009-07-01 | 2009-07-06 | 149, 116 | 148.5d |  |  |
| 121 | 1.17.4 | System Integration Test sign-off |  | 1d | 2009-11-23 | 2009-11-23 | 149, 116 | 48d |  | finish no earlier than 2009-11-23 |
| 122 | 1.18 | **Execute User Acceptance Test (UAT) in SH2** |  | 12d | 2009-11-24 | 2009-12-09 |  | 36d |  |  |
| 123 | 1.18.1 | Execute UAT |  | 9d | 2009-11-24 | 2009-12-04 |  | 39d |  | finish no earlier than 2009-12-04 |
| 124 | 1.18.2 | Financial Close |  | 1d | 2009-12-04 | 2009-12-04 |  | 39d |  | finish no earlier than 2009-12-04 |
| 125 | 1.18.3 | Issue retesting |  | 3d | 2009-12-07 | 2009-12-09 |  | 36d |  | start no earlier than 2009-12-05 |
| 126 | 1.19 | UAT sign off |  | 1d | 2009-12-10 | 2009-12-10 |  | 34d | 0d | start no earlier than 2009-12-10 |
| 127 | 1.20 | **Cutover weekend & Controlled Start** |  | 2d? | 2009-12-10 | 2009-12-14 | 126 | 33d |  |  |
| 128 | 1.20.1 | Netweaver/Adobe Document Server Update (Snowbell) |  | 1d? | 2009-12-11 | 2009-12-11 |  | 34d |  |  |
| 129 | 1.20.2 | System message put out on SAP |  | 0.25d | 2009-12-11 | 2009-12-11 |  | 34.75d |  |  |
| 130 | 1.20.3 | System message put out on SAPWeb pages |  | 0.25d | 2009-12-11 | 2009-12-11 |  | 34.75d |  |  |
| 131 | 1.20.4 | Update production (detailed weekend cutover plan in a separate document) |  | 1d? | 2009-12-11 | 2009-12-11 |  | 34d |  |  |
| 132 | 1.20.5 | Production validation | milestone | 0d? | 2009-12-10 | 2009-12-10 |  | 35d |  |  |
| 133 | 1.20.6 | Go/No Go approval | milestone | 0d? | 2009-12-10 | 2009-12-10 |  | 35d |  |  |
| 134 | 1.20.7 | Updated production available |  | 1d? | 2009-12-14 | 2009-12-14 |  | 33d |  | start no earlier than 2009-12-14 |
| 135 | 1.21 | First Calendar 2010 Payroll | milestone | 0d | 2009-12-22 | 2009-12-22 |  | 27d | 2d | start no earlier than 2009-12-22 |
| 136 | 1.22 | Freeze Ends |  | 1d | 2009-12-24 | 2009-12-24 | 135 | 25d |  | finish no earlier than 2009-12-24 |
| 137 | 1.23 | **Following dates & sequence to be confirmed** |  | 152d? | 2009-07-01 | 2010-01-28 |  | 0d |  |  |
| 138 | 1.23.1 | SF6 Refresh w/ 10/19/2009 snapshot (no data scrambling) |  | 3d | 2009-11-02 | 2009-11-04 |  | 61d |  | start no earlier than 2009-11-01 |
| 139 | 1.23.2 | **SF6 Update** |  | 1d? | 2009-07-01 | 2009-07-01 |  | 145.5d |  |  |
| 140 | 1.23.2.1 | Import post snapshot production transports (delta from 10/20 to 10/30) |  | 0.5d | 2009-07-01 | 2009-07-01 |  | 151.5d |  |  |
| 141 | 1.23.2.2 | Apply kernel update |  | 0.5d | 2009-07-01 | 2009-07-01 |  | 151.5d |  |  |
| 142 | 1.23.2.3 | Upgrade Oracle db |  | 0.5d | 2009-07-01 | 2009-07-01 |  | 151.5d |  |  |
| 143 | 1.23.2.4 | Iinstall basis enhancement pack 1 |  | 1d? | 2009-07-01 | 2009-07-01 |  | 151d |  |  |
| 144 | 1.23.2.5 | Install ECC enhancement pack 4 |  | 1d? | 2009-07-01 | 2009-07-01 |  | 151d |  |  |
| 145 | 1.23.2.6 | Import support packages |  | 1d | 2009-07-01 | 2009-07-01 |  | 151d |  |  |
| 146 | 1.23.2.7 | Apply BSI Tax Factory Update |  | 0.25d | 2009-07-01 | 2009-07-01 |  | 151.75d |  |  |
| 147 | 1.23.2.8 | Import SF3 transports & post-update DEV transports (to be tested during SI & UAT) |  | 1d | 2009-07-01 | 2009-07-01 |  | 151d |  |  |
| 148 | 1.23.2.9 | Execute trial balance and compare with TB from 10/20 |  | 0.5d | 2009-07-01 | 2009-07-01 |  | 151.5d |  |  |
| 149 | 1.23.2.10 | Execute action log |  | 0.5d | 2009-07-01 | 2009-07-01 |  | 145.5d | 0d |  |
| 150 | 1.23.2.11 | Execute DWH extracts and comparison |  | 1d | 2009-07-01 | 2009-07-01 |  | 151d |  |  |
| 151 | 1.23.3 | SF7 Update |  | 1d? | 2009-12-01 | 2009-12-01 |  | 42d |  | start no earlier than 2009-12-01 |
| 152 | 1.23.4 | SH2 Status Change |  | 15d? | 2009-12-11 | 2009-12-31 |  | 20d |  | finish no earlier than 2009-12-31 |
| 153 | 1.23.5 | SH1 Status Change |  | 15d? | 2009-12-11 | 2009-12-31 |  | 20d |  | finish no earlier than 2009-12-31 |
| 154 | 1.23.6 | SF5 Status Change |  | 15d? | 2009-12-11 | 2009-12-31 |  | 20d |  | finish no earlier than 2009-12-31 |
| 155 | 1.23.7 | PS1 Snapshot for SF5 |  | 1d? | 2009-12-16 | 2009-12-16 |  | 31d |  | start no earlier than 2009-12-16 |
| 156 | 1.23.8 | SF5 System refresh & update |  | 4d? | 2010-01-04 | 2010-01-07 |  | 14.75d | 0d | finish no earlier than 2010-01-07 |
| 157 | 1.23.9 | PS1 Snapshot for SF8 |  | 1d? | 2009-12-16 | 2009-12-16 |  | 31d |  | start no earlier than 2009-12-16 |
| 158 | 1.23.10 | SF8 System Refresh & Update |  | 1d? | 2010-01-28 | 2010-01-28 |  | 0d |  | start no earlier than 2010-01-28 |

| ID | WBS | Task | Duration | Start | Finish | Predecessors | Total slack | Resources | Work |
| --- | --- | --- | --- | --- | --- | --- | --- | --- | --- |
| 159 | 1.24 | **Zuttreq updates** | 0.25d | 2010-01-08 | 2010-01-08 |  | 14.75d |  | 2h |
| 160 | 1.24.1 | Change target system in Zuttreq | 0.25d | 2010-01-08 | 2010-01-08 | 156 | 14.75d | Wai-Ming | 2h |
